# Coil Schedule - 3 + Magnet Assembly

Schedule from MS Project, 2016-12-12 to 2023-06-30.
Fermi National Accelerator Laboratory

## Calendars

- Standard: Mon-Fri 08:00-12:00, 13:00-17:00; Sat-Sun off.

## Schedule

| ID | WBS | Task | Type | Duration | Start | Finish | Predecessors | Total slack | Free slack |
| --- | --- | --- | --- | --- | --- | --- | --- | --- | --- |
| 1 | 1 | **Magnet 1 Coils 1,2,3** |  | 469d | 2016-12-12 | 2018-09-27 |  | 285d |  |
| 2 | 1.1 | Procure Strand Coil 1 | milestone | 0d | 2016-12-12 | 2016-12-12 | 3SF-250d | 1710d |  |
| 3 | 1.2 | Fabricate Cable Coil 1 |  | 35d | 2017-11-27 | 2018-01-15 | 5SF | 1425d | 0d |
| 4 | 1.3 | Procure Parts Coil 1 | milestone | 0d | 2017-07-24 | 2017-07-24 | 5SF-125d | 1550d |  |
| 5 | 1.4 | Fabricate Coil 1 | manual | 84d | 2018-01-15 | 2018-05-10 |  |  |  |
| 6 | 1.5 | Procure Strand Coil 2 | milestone | 0d | 2017-02-20 | 2017-02-20 | 7SF-250d | 1660d |  |
| 7 | 1.6 | Fabricate Cable Coil 2 |  | 35d | 2018-02-05 | 2018-03-26 | 9SF | 1375d | 0d |
| 8 | 1.7 | Procure Parts Coil 2 | milestone | 0d | 2017-10-02 | 2017-10-02 | 9SF-125d | 1500d |  |
| 9 | 1.8 | Fabricate Coil 2 |  | 84d | 2018-03-26 | 2018-07-19 | 5FF+50d | 0d |  |
| 10 | 1.9 | Procure Strand Coil 3 | milestone | 0d | 2017-05-01 | 2017-05-01 | 11SF-250d | 1610d |  |
| 11 | 1.10 | Fabricate Cable Coil 3 |  | 35d | 2018-04-16 | 2018-06-04 | 13SF | 1325d | 0d |
| 12 | 1.11 | Procure Parts Coil 3 | milestone | 0d | 2017-12-11 | 2017-12-11 | 13SF-125d | 1450d |  |
| 13 | 1.12 | Fabricate Coil 3 |  | 84d | 2018-06-04 | 2018-09-27 | 9FF+50d | 0d |  |
| 14 | 2 | **Magnet 1 Assembly** |  | 65d | 2018-08-24 | 2018-11-22 |  | 976d |  |
| 15 | 2.1 | Yoke Shell Assembly |  | 20d | 2018-08-24 | 2018-09-20 | 13FS-25d | 981d | 5d |
| 16 | 2.2 | Coil Acceptance |  | 12d | 2018-09-28 | 2018-10-15 | 13, 15 | 976d | 0d |
| 17 | 2.3 | Coil Pack Assembly |  | 20d | 2018-10-16 | 2018-11-12 | 16 | 976d | 0d |
| 18 | 2.4 | Magnet Pre-load |  | 8d | 2018-11-13 | 2018-11-22 | 17 | 976d | 0d |
| 19 | 3 | **Magnet Rework Slot 1** |  | 60d | 2018-11-30 | 2019-02-21 |  | 976d |  |
| 20 | 3.1 | Dis Assemble Coil Pack |  | 20d | 2018-11-30 | 2018-12-27 | 18FS+5d | 976d | 0d |
| 21 | 3.2 | Coil Acceptance |  | 12d | 2018-12-28 | 2019-01-14 | 20 | 976d | 0d |
| 22 | 3.3 | Coil Pack Assembly |  | 20d | 2019-01-15 | 2019-02-11 | 21 | 976d | 0d |
| 23 | 3.4 | Magnet Pre-load |  | 8d | 2019-02-12 | 2019-02-21 | 22 | 976d | 20d |
| 24 | 4 | **Magnet 2 Coils 4,5,6** |  | 469d | 2017-07-10 | 2019-04-25 |  | 285d |  |
| 25 | 4.1 | Procure Strand Coil 4 | milestone | 0d | 2017-07-10 | 2017-07-10 | 26SF-250d | 1560d |  |
| 26 | 4.2 | Fabricate Cable Coil 4 |  | 35d | 2018-06-25 | 2018-08-13 | 28SF | 1275d | 0d |
| 27 | 4.3 | Procure Parts Coil 4 | milestone | 0d | 2018-02-19 | 2018-02-19 | 28SF-125d | 1400d |  |
| 28 | 4.4 | Fabricate Coil 4 |  | 84d | 2018-08-13 | 2018-12-06 | 13FF+50d | 0d |  |
| 29 | 4.5 | Procure Strand Coil 5 | milestone | 0d | 2017-09-18 | 2017-09-18 | 30SF-250d | 1510d |  |
| 30 | 4.6 | Fabricate Cable Coil 5 |  | 35d | 2018-09-03 | 2018-10-22 | 32SF | 1225d | 0d |
| 31 | 4.7 | Procure Parts Coil 5 | milestone | 0d | 2018-04-30 | 2018-04-30 | 32SF-125d | 1350d |  |
| 32 | 4.8 | Fabricate Coil 5 |  | 84d | 2018-10-22 | 2019-02-14 | 28FF+50d | 0d |  |
| 33 | 4.9 | Procure Strand Coil 6 | milestone | 0d | 2017-11-27 | 2017-11-27 | 34SF-250d | 1460d |  |
| 34 | 4.10 | Fabricate Cable Coil 6 |  | 35d | 2018-11-12 | 2018-12-31 | 36SF | 1175d | 0d |
| 35 | 4.11 | Procure Parts Coil 6 | milestone | 0d | 2018-07-09 | 2018-07-09 | 36SF-125d | 1300d |  |
| 36 | 4.12 | Fabricate Coil 6 |  | 84d | 2018-12-31 | 2019-04-25 | 32FF+50d | 0d |  |

| ID | WBS | Task | Type | Duration | Start | Finish | Predecessors | Total slack | Free slack |
| --- | --- | --- | --- | --- | --- | --- | --- | --- | --- |
| 37 | 5 | **Magnet 2 Assembly** |  | 65d | 2019-03-22 | 2019-06-20 |  | 951d |  |
| 38 | 5.1 | Yoke Shell Assembly |  | 20d | 2019-03-22 | 2019-04-18 | 36FS-25d, 23 | 956d | 5d |
| 39 | 5.2 | Coil Acceptance |  | 12d | 2019-04-26 | 2019-05-13 | 38, 36 | 951d | 0d |
| 40 | 5.3 | Coil Pack Assembly |  | 20d | 2019-05-14 | 2019-06-10 | 39 | 951d | 0d |
| 41 | 5.4 | Magnet Pre-load |  | 8d | 2019-06-11 | 2019-06-20 | 40 | 951d | 0d |
| 42 | 6 | **Second Tooling Line** |  | 20d | 2019-06-21 | 2019-07-18 |  | 951d |  |
| 43 | 6.1 | Tooling Setup |  | 20d | 2019-06-21 | 2019-07-18 | 41 | 951d | 0d |
| 44 | 7 | **Magnet Rework Slot 2** |  | 60d | 2019-07-19 | 2019-10-10 |  | 951d |  |
| 45 | 7.1 | Dis Assemble Coil Pack |  | 20d | 2019-07-19 | 2019-08-15 | 43 | 951d | 0d |
| 46 | 7.2 | Coil Acceptance |  | 12d | 2019-08-16 | 2019-09-02 | 45 | 951d | 0d |
| 47 | 7.3 | Coil Pack Assembly |  | 20d | 2019-09-03 | 2019-09-30 | 46 | 951d | 0d |
| 48 | 7.4 | Magnet Pre-load |  | 8d | 2019-10-01 | 2019-10-10 | 47 | 971d |  |
| 49 | 8 | **Magnet 3 Coils 7,8,9** |  | 419d | 2018-02-05 | 2019-09-12 |  | 285d |  |
| 50 | 8.1 | Procure Strand Coil 7 | milestone | 0d | 2018-02-05 | 2018-02-05 | 51SF-250d | 1410d |  |
| 51 | 8.2 | Fabricate Cable Coil 7 |  | 35d | 2019-01-21 | 2019-03-11 | 53SF | 1125d | 0d |
| 52 | 8.3 | Procure Parts Coil 7 | milestone | 0d | 2018-09-17 | 2018-09-17 | 53SF-125d | 1250d |  |
| 53 | 8.4 | Fabricate Coil 7 |  | 84d | 2019-03-11 | 2019-07-04 | 36FF+50d | 0d |  |
| 54 | 8.5 | Procure Strand Coil 8 | milestone | 0d | 2018-03-12 | 2018-03-12 | 55SF-250d | 1385d |  |
| 55 | 8.6 | Fabricate Cable Coil 8 |  | 35d | 2019-02-25 | 2019-04-15 | 57SF | 1100d | 0d |
| 56 | 8.7 | Procure Parts Coil 8 | milestone | 0d | 2018-10-22 | 2018-10-22 | 57SF-125d | 1225d |  |
| 57 | 8.8 | Fabricate Coil 8 |  | 84d | 2019-04-15 | 2019-08-08 | 53FF+25d | 0d |  |
| 58 | 8.9 | Procure additional R and I Tooling | milestone | 0d | 2018-10-22 | 2018-10-22 | 57SF-125d | 1225d |  |
| 59 | 8.10 | Procure Strand Coil 9 | milestone | 0d | 2018-04-16 | 2018-04-16 | 60SF-250d | 1360d |  |
| 60 | 8.11 | Fabricate Cable Coil 9 |  | 35d | 2019-04-01 | 2019-05-20 | 62SF | 1075d | 0d |
| 61 | 8.12 | Procure Parts Coil 9 | milestone | 0d | 2018-11-26 | 2018-11-26 | 62SF-125d | 1200d |  |
| 62 | 8.13 | Fabricate Coil 9 |  | 84d | 2019-05-20 | 2019-09-12 | 57FF+25d | 0d |  |

| ID | WBS | Task | Type | Duration | Start | Finish | Predecessors | Total slack | Free slack |
| --- | --- | --- | --- | --- | --- | --- | --- | --- | --- |
| 63 | 9 | **Magnet 3 Assembly** |  | 65d | 2019-08-09 | 2019-11-07 |  | 951d |  |
| 64 | 9.1 | Yoke Shell Assembly |  | 20d | 2019-08-09 | 2019-09-05 | 62FS-25d | 956d | 5d |
| 65 | 9.2 | Coil Acceptance |  | 12d | 2019-09-13 | 2019-09-30 | 62, 64 | 951d | 0d |
| 66 | 9.3 | Coil Pack Assembly |  | 20d | 2019-10-01 | 2019-10-28 | 65, 47 | 951d | 0d |
| 67 | 9.4 | Magnet Pre-load |  | 8d | 2019-10-29 | 2019-11-07 | 66 | 951d |  |
| 68 | 10 | **Magnet 4 Coils 10,11** |  | 394d | 2018-05-21 | 2019-11-21 |  | 285d |  |
| 69 | 10.1 | Procure Strand Coil 10 | milestone | 0d | 2018-05-21 | 2018-05-21 | 70SF-250d | 1335d |  |
| 70 | 10.2 | Fabricate Cable Coil 10 |  | 35d | 2019-05-06 | 2019-06-24 | 72SF | 1050d | 0d |
| 71 | 10.3 | Procure Parts Coil 10 | milestone | 0d | 2018-12-31 | 2018-12-31 | 72SF-125d | 1175d |  |
| 72 | 10.4 | Fabricate Coil 10 |  | 84d | 2019-06-24 | 2019-10-17 | 62FF+25d | 0d |  |
| 73 | 10.5 | Procure Strand Coil 11 | milestone | 0d | 2018-06-25 | 2018-06-25 | 74SF-250d | 1310d |  |
| 74 | 10.6 | Fabricate Cable Coil 11 |  | 35d | 2019-06-10 | 2019-07-29 | 76SF | 1025d | 0d |
| 75 | 10.7 | Procure Parts Coil 11 | milestone | 0d | 2019-02-04 | 2019-02-04 | 76SF-125d | 1150d |  |
| 76 | 10.8 | Fabricate Coil 11 |  | 84d | 2019-07-29 | 2019-11-21 | 72FF+25d | 0d |  |
| 77 | 11 | **Magnet 4 Assembly** |  | 65d | 2019-10-18 | 2020-01-16 |  | 901d |  |
| 78 | 11.1 | Yoke Shell Assembly |  | 20d | 2019-10-18 | 2019-11-14 | 76FS-25d | 906d | 5d |
| 79 | 11.2 | Coil Acceptance |  | 12d | 2019-11-22 | 2019-12-09 | 78, 76 | 901d | 0d |
| 80 | 11.3 | Coil Pack Assembly |  | 20d | 2019-12-10 | 2020-01-06 | 79 | 901d | 0d |
| 81 | 11.4 | Magnet Pre-load |  | 8d | 2020-01-07 | 2020-01-16 | 80 | 901d |  |
| 82 | 12 | **Magnet 5 Coils 12,13** |  | 394d | 2018-07-30 | 2020-01-30 |  | 285d |  |
| 83 | 12.1 | Procure Strand Coil 12 | milestone | 0d | 2018-07-30 | 2018-07-30 | 84SF-250d | 1285d |  |
| 84 | 12.2 | Fabricate Cable Coil 12 |  | 35d | 2019-07-15 | 2019-09-02 | 86SF | 1000d | 0d |
| 85 | 12.3 | Procure Parts Coil 12 | milestone | 0d | 2019-03-11 | 2019-03-11 | 86SF-125d | 1125d |  |
| 86 | 12.4 | Fabricate Coil 12 |  | 84d | 2019-09-02 | 2019-12-26 | 76FF+25d | 0d |  |
| 87 | 12.5 | Procure Strand Coil 13 | milestone | 0d | 2018-09-03 | 2018-09-03 | 88SF-250d | 1260d |  |
| 88 | 12.6 | Fabricate Cable Coil 13 |  | 35d | 2019-08-19 | 2019-10-07 | 90SF | 975d | 0d |
| 89 | 12.7 | Procure Parts Coil 13 | milestone | 0d | 2019-04-15 | 2019-04-15 | 90SF-125d | 1100d |  |
| 90 | 12.8 | Fabricate Coil 13 |  | 84d | 2019-10-07 | 2020-01-30 | 86FF+25d | 0d |  |

| ID | WBS | Task | Type | Duration | Start | Finish | Predecessors | Total slack | Free slack |
| --- | --- | --- | --- | --- | --- | --- | --- | --- | --- |
| 91 | 13 | **Magnet 5 Assembly** |  | 60d | 2019-12-27 | 2020-03-19 |  | 856d |  |
| 92 | 13.1 | Yoke Shell Assembly |  | 20d | 2019-12-27 | 2020-01-23 | 90FS-25d | 856d | 0d |
| 93 | 13.2 | Coil Acceptance |  | 12d | 2020-01-24 | 2020-02-10 | 92, 76 | 856d | 0d |
| 94 | 13.3 | Coil Pack Assembly |  | 20d | 2020-02-11 | 2020-03-09 | 93 | 856d | 0d |
| 95 | 13.4 | Magnet Pre-load |  | 8d | 2020-03-10 | 2020-03-19 | 94 | 856d |  |
| 96 | 14 | **Magnet 6 coils 14,15** |  | 394d | 2018-10-08 | 2020-04-09 |  | 285d |  |
| 97 | 14.1 | Procure Strand Coil 14 | milestone | 0d | 2018-10-08 | 2018-10-08 | 98SF-250d | 1235d |  |
| 98 | 14.2 | Fabricate Cable Coil 14 |  | 35d | 2019-09-23 | 2019-11-11 | 100SF | 950d | 0d |
| 99 | 14.3 | Procure Parts Coil 14 | milestone | 0d | 2019-05-20 | 2019-05-20 | 100SF-125d | 1075d |  |
| 100 | 14.4 | Fabricate Coil 14 |  | 84d | 2019-11-11 | 2020-03-05 | 90FF+25d | 0d |  |
| 101 | 14.5 | Procure Strand Coil 15 | milestone | 0d | 2018-11-12 | 2018-11-12 | 102SF-250d | 1210d |  |
| 102 | 14.6 | Fabricate Cable Coil 15 |  | 35d | 2019-10-28 | 2019-12-16 | 104SF | 925d | 0d |
| 103 | 14.7 | Procure Parts Coil 15 | milestone | 0d | 2019-06-24 | 2019-06-24 | 104SF-125d | 1050d |  |
| 104 | 14.8 | Fabricate Coil 15 |  | 84d | 2019-12-16 | 2020-04-09 | 100FF+25d | 0d |  |
| 105 | 15 | **Magnet 6 Assembly** |  | 65d | 2020-03-06 | 2020-06-04 |  | 721d |  |
| 106 | 15.1 | Yoke Shell Assembly |  | 20d | 2020-03-06 | 2020-04-02 | 104FS-25d | 726d | 5d |
| 107 | 15.2 | Coil Acceptance |  | 12d | 2020-04-10 | 2020-04-27 | 106, 104 | 721d | 0d |
| 108 | 15.3 | Coil Pack Assembly |  | 20d | 2020-04-28 | 2020-05-25 | 107 | 721d | 0d |
| 109 | 15.4 | Magnet Pre-load |  | 8d | 2020-05-26 | 2020-06-04 | 108 | 721d | 0d |
| 110 | 16 | **Magnet Rework Slot 3** |  | 60d | 2020-06-05 | 2020-08-27 |  | 721d |  |
| 111 | 16.1 | Dis Assemble Coil Pack |  | 20d | 2020-06-05 | 2020-07-02 | 109 | 721d | 0d |
| 112 | 16.2 | Coil Acceptance |  | 12d | 2020-07-03 | 2020-07-20 | 111 | 721d | 0d |
| 113 | 16.3 | Coil Pack Assembly |  | 20d | 2020-07-21 | 2020-08-17 | 112 | 721d | 0d |
| 114 | 16.4 | Magnet Pre-load |  | 8d | 2020-08-18 | 2020-08-27 | 113 | 741d |  |

| ID | WBS | Task | Type | Duration | Start | Finish | Predecessors | Total slack | Free slack |
| --- | --- | --- | --- | --- | --- | --- | --- | --- | --- |
| 115 | 17 | **Magnet 7 Coils 16,17,18** |  | 419d | 2018-12-17 | 2020-07-23 |  | 285d |  |
| 116 | 17.1 | Procure Strand Coil 16 | milestone | 0d | 2018-12-17 | 2018-12-17 | 117SF-250d | 1185d |  |
| 117 | 17.2 | Fabricate Cable Coil 16 |  | 35d | 2019-12-02 | 2020-01-20 | 119SF | 900d | 0d |
| 118 | 17.3 | Procure Parts Coil 16 | milestone | 0d | 2019-07-29 | 2019-07-29 | 119SF-125d | 1025d |  |
| 119 | 17.4 | Fabricate Coil 16 |  | 84d | 2020-01-20 | 2020-05-14 | 104FF+25d | 0d |  |
| 120 | 17.5 | Procure Strand Coil 17 | milestone | 0d | 2019-01-21 | 2019-01-21 | 121SF-250d | 1160d |  |
| 121 | 17.6 | Fabricate Cable Coil 17 |  | 35d | 2020-01-06 | 2020-02-24 | 123SF | 875d | 0d |
| 122 | 17.7 | Procure Parts Coil 17 | milestone | 0d | 2019-09-02 | 2019-09-02 | 123SF-125d | 1000d |  |
| 123 | 17.8 | Fabricate Coil 17 |  | 84d | 2020-02-24 | 2020-06-18 | 119FF+25d | 0d |  |
| 124 | 17.9 | Procure Strand Coil 18 | milestone | 0d | 2019-02-25 | 2019-02-25 | 125SF-250d | 1135d |  |
| 125 | 17.10 | Fabricate Cable Coil 18 |  | 35d | 2020-02-10 | 2020-03-30 | 127SF | 850d | 0d |
| 126 | 17.11 | Procure Parts Coil 18 | milestone | 0d | 2019-10-07 | 2019-10-07 | 127SF-125d | 975d |  |
| 127 | 17.12 | Fabricate Coil 18 |  | 84d | 2020-03-30 | 2020-07-23 | 123FF+25d | 0d |  |
| 128 | 18 | **Magnet 7 Assembly** |  | 70d | 2020-06-19 | 2020-09-24 |  | 721d |  |
| 129 | 18.1 | Yoke Shell Assembly |  | 20d | 2020-06-19 | 2020-07-16 | 127FS-25d | 731d | 5d |
| 130 | 18.2 | Coil Acceptance |  | 12d | 2020-07-24 | 2020-08-10 | 129, 127 | 726d | 5d |
| 131 | 18.3 | Coil Pack Assembly |  | 20d | 2020-08-18 | 2020-09-14 | 130, 113 | 721d | 0d |
| 132 | 18.4 | Magnet Pre-load |  | 8d | 2020-09-15 | 2020-09-24 | 131 | 721d |  |
| 133 | 19 | **Magnet 8 Coils 19,20** |  | 388d | 2019-03-22 | 2020-09-15 |  | 285d |  |
| 134 | 19.1 | Procure Strand Coil 19 | milestone | 0d | 2019-03-22 | 2019-03-22 | 135SF-250d | 1116d |  |
| 135 | 19.2 | Fabricate Cable Coil 19 |  | 35d | 2020-03-06 | 2020-04-24 | 137SF | 831d | 0d |
| 136 | 19.3 | Procure Parts Coil 19 | milestone | 0d | 2019-11-01 | 2019-11-01 | 137SF-125d | 956d |  |
| 137 | 19.4 | Fabricate Coil 19 |  | 84d | 2020-04-24 | 2020-08-19 | 127FF+19d | 0d |  |
| 138 | 19.5 | Procure additional R Tooling | milestone | 0d | 2019-11-01 | 2019-11-01 | 137SF-125d | 956d |  |
| 139 | 19.6 | Procure Strand Coil 20 | milestone | 0d | 2019-04-18 | 2019-04-18 | 140SF-250d | 1097d |  |
| 140 | 19.7 | Fabricate Cable Coil 20 |  | 35d | 2020-04-02 | 2020-05-21 | 142SF | 812d | 0d |
| 141 | 19.8 | Procure Parts Coil 20 | milestone | 0d | 2019-11-28 | 2019-11-28 | 142SF-125d | 937d |  |
| 142 | 19.9 | Fabricate Coil 20 |  | 84d | 2020-05-21 | 2020-09-15 | 137FF+19d | 0d |  |

| ID | WBS | Task | Type | Duration | Start | Finish | Predecessors | Total slack | Free slack |
| --- | --- | --- | --- | --- | --- | --- | --- | --- | --- |
| 143 | 20 | **Magnet 8 Assembly** |  | 65d | 2020-08-12 | 2020-11-10 |  | 688d |  |
| 144 | 20.1 | Yoke Shell Assembly |  | 20d | 2020-08-12 | 2020-09-08 | 142FS-25d | 693d | 5d |
| 145 | 20.2 | Coil Acceptance |  | 12d | 2020-09-16 | 2020-10-01 | 144, 142 | 688d | 0d |
| 146 | 20.3 | Coil Pack Assembly |  | 20d | 2020-10-02 | 2020-10-29 | 145 | 688d | 0d |
| 147 | 20.4 | Magnet Pre-load |  | 8d | 2020-10-30 | 2020-11-10 | 146 | 688d |  |
| 148 | 21 | **Magnet 9 Coils 21,22** |  | 388d | 2019-05-15 | 2020-11-06 |  | 285d |  |
| 149 | 21.1 | Procure Strand Coil 21 | milestone | 0d | 2019-05-15 | 2019-05-15 | 150SF-250d | 1078d |  |
| 150 | 21.2 | Fabricate Cable Coil 21 |  | 35d | 2020-04-29 | 2020-06-17 | 152SF | 793d | 0d |
| 151 | 21.3 | Procure Parts Coil 21 | milestone | 0d | 2019-12-25 | 2019-12-25 | 152SF-125d | 918d |  |
| 152 | 21.4 | Fabricate Coil 21 |  | 84d | 2020-06-17 | 2020-10-12 | 142FF+19d | 0d |  |
| 153 | 21.5 | Procure Strand Coil 22 | milestone | 0d | 2019-06-11 | 2019-06-11 | 154SF-250d | 1059d |  |
| 154 | 21.6 | Fabricate Cable Coil 22 |  | 35d | 2020-05-26 | 2020-07-14 | 156SF | 774d | 0d |
| 155 | 21.7 | Procure Parts Coil 22 | milestone | 0d | 2020-01-21 | 2020-01-21 | 156SF-125d | 899d |  |
| 156 | 21.8 | Fabricate Coil 22 |  | 84d | 2020-07-14 | 2020-11-06 | 152FF+19d | 0d |  |
| 157 | 22 | **Magnet 9 Assembly** |  | 65d | 2020-10-05 | 2021-01-01 |  | 650d |  |
| 158 | 22.1 | Yoke Shell Assembly |  | 20d | 2020-10-05 | 2020-10-30 | 156FS-25d | 655d | 5d |
| 159 | 22.2 | Coil Acceptance |  | 12d | 2020-11-09 | 2020-11-24 | 156, 158 | 650d | 0d |
| 160 | 22.3 | Coil Pack Assembly |  | 20d | 2020-11-25 | 2020-12-22 | 159 | 650d | 0d |
| 161 | 22.4 | Magnet Pre-load |  | 8d | 2020-12-23 | 2021-01-01 | 160 | 650d |  |
| 162 | 23 | **Magnet 10 Coils 23,24** |  | 388d | 2019-07-08 | 2020-12-30 |  | 285d |  |
| 163 | 23.1 | Procure Strand Coil 23 | milestone | 0d | 2019-07-08 | 2019-07-08 | 164SF-250d | 1040d |  |
| 164 | 23.2 | Fabricate Cable Coil 23 |  | 35d | 2020-06-22 | 2020-08-10 | 166SF | 755d | 0d |
| 165 | 23.3 | Procure Parts Coil 23 | milestone | 0d | 2020-02-17 | 2020-02-17 | 166SF-125d | 880d |  |
| 166 | 23.4 | Fabricate Coil 23 |  | 84d | 2020-08-10 | 2020-12-03 | 156FF+19d | 0d |  |
| 167 | 23.5 | Procure Strand Coil 24 | milestone | 0d | 2019-08-02 | 2019-08-02 | 168SF-250d | 1021d |  |
| 168 | 23.6 | Fabricate Cable Coil 24 |  | 35d | 2020-07-17 | 2020-09-04 | 170SF | 736d | 0d |
| 169 | 23.7 | Procure Parts Coil 24 | milestone | 0d | 2020-03-13 | 2020-03-13 | 170SF-125d | 861d |  |
| 170 | 23.8 | Fabricate Coil 24 |  | 84d | 2020-09-04 | 2020-12-30 | 166FF+19d | 0d |  |

| ID | WBS | Task | Type | Duration | Start | Finish | Predecessors | Total slack | Free slack |
| --- | --- | --- | --- | --- | --- | --- | --- | --- | --- |
| 171 | 24 | **Magnet 10 Assembly** |  | 65d | 2020-11-26 | 2021-02-24 |  | 612d |  |
| 172 | 24.1 | Yoke Shell Assembly |  | 20d | 2020-11-26 | 2020-12-23 | 170FS-25d | 617d | 5d |
| 173 | 24.2 | Coil Acceptance |  | 12d | 2020-12-31 | 2021-01-15 | 172, 170 | 612d | 0d |
| 174 | 24.3 | Coil Pack Assembly |  | 20d | 2021-01-18 | 2021-02-12 | 173 | 612d | 0d |
| 175 | 24.4 | Magnet Pre-load |  | 8d | 2021-02-15 | 2021-02-24 | 174 | 612d |  |
| 176 | 25 | **Magnet 11 Coils 25,26** |  | 388d | 2019-08-29 | 2021-02-22 |  | 285d |  |
| 177 | 25.1 | Procure Strand Coil 25 | milestone | 0d | 2019-08-29 | 2019-08-29 | 178SF-250d | 1002d |  |
| 178 | 25.2 | Fabricate Cable Coil 25 |  | 35d | 2020-08-13 | 2020-10-01 | 180SF | 717d | 0d |
| 179 | 25.3 | Procure Parts Coil 25 | milestone | 0d | 2020-04-09 | 2020-04-09 | 180SF-125d | 842d |  |
| 180 | 25.4 | Fabricate Coil 25 |  | 84d | 2020-10-01 | 2021-01-26 | 170FF+19d | 0d |  |
| 181 | 25.5 | Procure Strand Coil 26 | milestone | 0d | 2019-09-25 | 2019-09-25 | 182SF-250d | 983d |  |
| 182 | 25.6 | Fabricate Cable Coil 26 |  | 35d | 2020-09-09 | 2020-10-28 | 184SF | 698d | 0d |
| 183 | 25.7 | Procure Parts Coil 26 | milestone | 0d | 2020-05-06 | 2020-05-06 | 184SF-125d | 823d |  |
| 184 | 25.8 | Fabricate Coil 26 |  | 84d | 2020-10-28 | 2021-02-22 | 180FF+19d | 0d |  |
| 185 | 26 | **Magnet 11 Assembly** |  | 65d | 2021-01-19 | 2021-04-19 |  | 574d |  |
| 186 | 26.1 | Yoke Shell Assembly |  | 20d | 2021-01-19 | 2021-02-15 | 184FS-25d | 579d | 5d |
| 187 | 26.2 | Coil Acceptance |  | 12d | 2021-02-23 | 2021-03-10 | 186, 184 | 574d | 0d |
| 188 | 26.3 | Coil Pack Assembly |  | 20d | 2021-03-11 | 2021-04-07 | 187 | 574d | 0d |
| 189 | 26.4 | Magnet Pre-load |  | 8d | 2021-04-08 | 2021-04-19 | 188 | 574d |  |
| 190 | 27 | **Magnet 12 Coils 27,28** |  | 388d | 2019-10-22 | 2021-04-15 |  | 285d |  |
| 191 | 27.1 | Procure Strand Coil 27 | milestone | 0d | 2019-10-22 | 2019-10-22 | 192SF-250d | 964d |  |
| 192 | 27.2 | Fabricate Cable Coil 27 |  | 35d | 2020-10-06 | 2020-11-24 | 194SF | 679d | 0d |
| 193 | 27.3 | Procure Parts Coil 27 | milestone | 0d | 2020-06-02 | 2020-06-02 | 194SF-125d | 804d |  |
| 194 | 27.4 | Fabricate Coil 27 |  | 84d | 2020-11-24 | 2021-03-19 | 184FF+19d | 0d |  |
| 195 | 27.5 | Procure Strand Coil 28 | milestone | 0d | 2019-11-18 | 2019-11-18 | 196SF-250d | 945d |  |
| 196 | 27.6 | Fabricate Cable Coil 28 |  | 35d | 2020-11-02 | 2020-12-21 | 198SF | 660d | 0d |
| 197 | 27.7 | Procure Parts Coil 28 | milestone | 0d | 2020-06-29 | 2020-06-29 | 198SF-125d | 785d |  |
| 198 | 27.8 | Fabricate Coil 28 |  | 84d | 2020-12-21 | 2021-04-15 | 194FF+19d | 0d |  |

| ID | WBS | Task | Type | Duration | Start | Finish | Predecessors | Total slack | Free slack | Constraint |
| --- | --- | --- | --- | --- | --- | --- | --- | --- | --- | --- |
| 199 | 28 | **Magnet 12 Assembly** |  | 65d | 2021-03-12 | 2021-06-10 |  | 536d |  |  |
| 200 | 28.1 | Yoke Shell Assembly |  | 20d | 2021-03-12 | 2021-04-08 | 198FS-25d | 541d | 5d |  |
| 201 | 28.2 | Coil Acceptance |  | 12d | 2021-04-16 | 2021-05-03 | 200, 198 | 536d | 0d |  |
| 202 | 28.3 | Coil Pack Assembly |  | 20d | 2021-05-04 | 2021-05-31 | 201 | 536d | 0d |  |
| 203 | 28.4 | Magnet Pre-load |  | 8d | 2021-06-01 | 2021-06-10 | 202 | 536d |  |  |
| 204 | 29 | **Magnet 13 Coils 29,30** |  | 388d | 2019-12-13 | 2021-06-08 |  | 285d |  |  |
| 205 | 29.1 | Procure Strand Coil 29 | milestone | 0d | 2019-12-13 | 2019-12-13 | 206SF-250d | 926d |  |  |
| 206 | 29.2 | Fabricate Cable Coil 29 |  | 35d | 2020-11-27 | 2021-01-15 | 208SF | 641d | 0d |  |
| 207 | 29.3 | Procure Parts Coil 29 | milestone | 0d | 2020-07-24 | 2020-07-24 | 208SF-125d | 766d |  |  |
| 208 | 29.4 | Fabricate Coil 29 |  | 84d | 2021-01-15 | 2021-05-12 | 198FF+19d | 0d |  |  |
| 209 | 29.5 | Procure Strand Coil 30 | milestone | 0d | 2020-01-09 | 2020-01-09 | 210SF-250d | 907d |  |  |
| 210 | 29.6 | Fabricate Cable Coil 30 |  | 35d | 2020-12-24 | 2021-02-11 | 212SF | 622d | 0d |  |
| 211 | 29.7 | Procure Parts Coil 30 | milestone | 0d | 2020-08-20 | 2020-08-20 | 212SF-125d | 747d |  |  |
| 212 | 29.8 | Fabricate Coil 30 |  | 84d | 2021-02-11 | 2021-06-08 | 208FF+19d | 0d |  |  |
| 213 | 30 | **Magnet 13 Assembly** |  | 65d | 2021-05-05 | 2021-08-03 |  | 498d |  |  |
| 214 | 30.1 | Yoke Shell Assembly |  | 20d | 2021-05-05 | 2021-06-01 | 212FS-25d | 503d | 5d |  |
| 215 | 30.2 | Coil Acceptance |  | 12d | 2021-06-09 | 2021-06-24 | 214, 212 | 498d | 0d |  |
| 216 | 30.3 | Coil Pack Assembly |  | 20d | 2021-06-25 | 2021-07-22 | 215 | 498d | 0d |  |
| 217 | 30.4 | Magnet Pre-load |  | 8d | 2021-07-23 | 2021-08-03 | 216 | 498d |  |  |
| 218 | 31 | **Magnet 14 Coils 31,32** |  | 388d | 2020-02-05 | 2021-07-30 |  | 285d |  |  |
| 219 | 31.1 | Procure Strand Coil 31 | milestone | 0d | 2020-02-05 | 2020-02-05 | 220SF-250d | 888d |  |  |
| 220 | 31.2 | Fabricate Cable Coil 31 |  | 35d | 2021-01-20 | 2021-03-10 | 222SF | 603d | 0d |  |
| 221 | 31.3 | Procure Parts Coil 31 | milestone | 0d | 2020-09-16 | 2020-09-16 | 222SF-125d | 728d |  |  |
| 222 | 31.4 | Fabricate Coil 31 |  | 84d | 2021-03-10 | 2021-07-05 | 212FF+19d | 0d |  |  |
| 223 | 31.5 | Procure Strand Coil 32 | milestone | 0d | 2020-03-03 | 2020-03-03 | 224SF-250d | 869d |  |  |
| 224 | 31.6 | Fabricate Cable Coil 32 |  | 35d | 2021-02-16 | 2021-04-06 | 226SF | 584d | 0d |  |
| 225 | 31.7 | Procure Parts Coil 32 | milestone | 0d | 2020-10-13 | 2020-10-13 | 226SF-125d | 709d |  | finish no earlier than 2020-10-05 |
| 226 | 31.8 | Fabricate Coil 32 |  | 84d | 2021-04-06 | 2021-07-30 | 222FF+19d | 0d |  |  |

| ID | WBS | Task | Type | Duration | Start | Finish | Predecessors | Total slack | Free slack |
| --- | --- | --- | --- | --- | --- | --- | --- | --- | --- |
| 227 | 32 | **Magnet 14 Assembly** |  | 65d | 2021-06-28 | 2021-09-24 |  | 460d |  |
| 228 | 32.1 | Yoke Shell Assembly |  | 20d | 2021-06-28 | 2021-07-23 | 226FS-25d | 465d | 5d |
| 229 | 32.2 | Coil Acceptance |  | 12d | 2021-08-02 | 2021-08-17 | 228, 226 | 460d | 0d |
| 230 | 32.3 | Coil Pack Assembly |  | 20d | 2021-08-18 | 2021-09-14 | 229 | 460d | 0d |
| 231 | 32.4 | Magnet Pre-load |  | 8d | 2021-09-15 | 2021-09-24 | 230 | 460d |  |
| 232 | 33 | **Magnet 15 Coils 33,34** |  | 388d | 2020-03-30 | 2021-09-22 |  | 285d |  |
| 233 | 33.1 | Procure Strand Coil 33 | milestone | 0d | 2020-03-30 | 2020-03-30 | 234SF-250d | 850d |  |
| 234 | 33.2 | Fabricate Cable Coil 33 |  | 35d | 2021-03-15 | 2021-05-03 | 236SF | 565d | 0d |
| 235 | 33.3 | Procure Parts Coil 33 | milestone | 0d | 2020-11-09 | 2020-11-09 | 236SF-125d | 690d |  |
| 236 | 33.4 | Fabricate Coil 33 |  | 84d | 2021-05-03 | 2021-08-26 | 226FF+19d | 0d |  |
| 237 | 33.5 | Procure Strand Coil 34 | milestone | 0d | 2020-04-24 | 2020-04-24 | 238SF-250d | 831d |  |
| 238 | 33.6 | Fabricate Cable Coil 34 |  | 35d | 2021-04-09 | 2021-05-28 | 240SF | 546d | 0d |
| 239 | 33.7 | Procure Parts Coil 34 | milestone | 0d | 2020-12-04 | 2020-12-04 | 240SF-125d | 671d |  |
| 240 | 33.8 | Fabricate Coil 34 |  | 84d | 2021-05-28 | 2021-09-22 | 236FF+19d | 0d |  |
| 241 | 34 | **Magnet 15 Assembly** |  | 65d | 2021-08-19 | 2021-11-17 |  | 422d |  |
| 242 | 34.1 | Yoke Shell Assembly |  | 20d | 2021-08-19 | 2021-09-15 | 240FS-25d | 427d | 5d |
| 243 | 34.2 | Coil Acceptance |  | 12d | 2021-09-23 | 2021-10-08 | 242, 240 | 422d | 0d |
| 244 | 34.3 | Coil Pack Assembly |  | 20d | 2021-10-11 | 2021-11-05 | 243 | 422d | 0d |
| 245 | 34.4 | Magnet Pre-load |  | 8d | 2021-11-08 | 2021-11-17 | 244 | 422d |  |
| 246 | 35 | **Magnet 16 Coils 35,36** |  | 388d | 2020-05-21 | 2021-11-15 |  | 285d |  |
| 247 | 35.1 | Procure Strand Coil 35 | milestone | 0d | 2020-05-21 | 2020-05-21 | 248SF-250d | 812d |  |
| 248 | 35.2 | Fabricate Cable Coil 35 |  | 35d | 2021-05-06 | 2021-06-24 | 250SF | 527d | 0d |
| 249 | 35.3 | Procure Parts Coil 35 | milestone | 0d | 2020-12-31 | 2020-12-31 | 250SF-125d | 652d |  |
| 250 | 35.4 | Fabricate Coil 35 |  | 84d | 2021-06-24 | 2021-10-19 | 240FF+19d | 0d |  |
| 251 | 35.5 | Procure Strand Coil 36 | milestone | 0d | 2020-06-17 | 2020-06-17 | 252SF-250d | 793d |  |
| 252 | 35.6 | Fabricate Cable Coil 36 |  | 35d | 2021-06-02 | 2021-07-21 | 254SF | 508d | 0d |
| 253 | 35.7 | Procure Parts Coil 36 | milestone | 0d | 2021-01-27 | 2021-01-27 | 254SF-125d | 633d |  |
| 254 | 35.8 | Fabricate Coil 36 |  | 84d | 2021-07-21 | 2021-11-15 | 250FF+19d | 0d |  |

| ID | WBS | Task | Type | Duration | Start | Finish | Predecessors | Total slack | Free slack |
| --- | --- | --- | --- | --- | --- | --- | --- | --- | --- |
| 255 | 36 | **Magnet 16 Assembly** |  | 65d | 2021-10-12 | 2022-01-10 |  | 384d |  |
| 256 | 36.1 | Yoke Shell Assembly |  | 20d | 2021-10-12 | 2021-11-08 | 254FS-25d | 389d | 5d |
| 257 | 36.2 | Coil Acceptance |  | 12d | 2021-11-16 | 2021-12-01 | 256, 254 | 384d | 0d |
| 258 | 36.3 | Coil Pack Assembly |  | 20d | 2021-12-02 | 2021-12-29 | 257 | 384d | 0d |
| 259 | 36.4 | Magnet Pre-load |  | 8d | 2021-12-30 | 2022-01-10 | 258 | 384d |  |
| 260 | 37 | **Magnet 17 Coils 37,38** |  | 388d | 2020-07-14 | 2022-01-06 |  | 285d |  |
| 261 | 37.1 | Procure Strand Coil 37 | milestone | 0d | 2020-07-14 | 2020-07-14 | 262SF-250d | 774d |  |
| 262 | 37.2 | Fabricate Cable Coil 37 |  | 35d | 2021-06-29 | 2021-08-17 | 264SF | 489d | 0d |
| 263 | 37.3 | Procure Parts Coil 37 | milestone | 0d | 2021-02-23 | 2021-02-23 | 264SF-125d | 614d |  |
| 264 | 37.4 | Fabricate Coil 37 |  | 84d | 2021-08-17 | 2021-12-10 | 254FF+19d | 0d |  |
| 265 | 37.5 | Procure Strand Coil 38 | milestone | 0d | 2020-08-10 | 2020-08-10 | 266SF-250d | 755d |  |
| 266 | 37.6 | Fabricate Cable Coil 38 |  | 35d | 2021-07-26 | 2021-09-13 | 268SF | 470d | 0d |
| 267 | 37.7 | Procure Parts Coil 38 | milestone | 0d | 2021-03-22 | 2021-03-22 | 268SF-125d | 595d |  |
| 268 | 37.8 | Fabricate Coil 38 |  | 84d | 2021-09-13 | 2022-01-06 | 264FF+19d | 0d |  |
| 269 | 38 | **Magnet 17 Assembly** |  | 65d | 2021-12-03 | 2022-03-03 |  | 346d |  |
| 270 | 38.1 | Yoke Shell Assembly |  | 20d | 2021-12-03 | 2021-12-30 | 268FS-25d | 351d | 5d |
| 271 | 38.2 | Coil Acceptance |  | 12d | 2022-01-07 | 2022-01-24 | 270, 268 | 346d | 0d |
| 272 | 38.3 | Coil Pack Assembly |  | 20d | 2022-01-25 | 2022-02-21 | 271 | 346d | 0d |
| 273 | 38.4 | Magnet Pre-load |  | 8d | 2022-02-22 | 2022-03-03 | 272 | 346d |  |
| 274 | 39 | **Magnet 18 Coils 39,40** |  | 388d | 2020-09-04 | 2022-03-01 |  | 285d |  |
| 275 | 39.1 | Procure Strand Coil 39 | milestone | 0d | 2020-09-04 | 2020-09-04 | 276SF-250d | 736d |  |
| 276 | 39.2 | Fabricate Cable Coil 39 |  | 35d | 2021-08-20 | 2021-10-08 | 278SF | 451d | 0d |
| 277 | 39.3 | Procure Parts Coil 39 | milestone | 0d | 2021-04-16 | 2021-04-16 | 278SF-125d | 576d |  |
| 278 | 39.4 | Fabricate Coil 39 |  | 84d | 2021-10-08 | 2022-02-02 | 268FF+19d | 0d |  |
| 279 | 39.5 | Procure Strand Coil 40 | milestone | 0d | 2020-10-01 | 2020-10-01 | 280SF-250d | 717d |  |
| 280 | 39.6 | Fabricate Cable Coil 40 |  | 35d | 2021-09-16 | 2021-11-04 | 282SF | 432d | 0d |
| 281 | 39.7 | Procure Parts Coil 40 | milestone | 0d | 2021-05-13 | 2021-05-13 | 282SF-125d | 557d |  |
| 282 | 39.8 | Fabricate Coil 40 |  | 84d | 2021-11-04 | 2022-03-01 | 278FF+19d | 0d |  |

| ID | WBS | Task | Type | Duration | Start | Finish | Predecessors | Total slack | Free slack |
| --- | --- | --- | --- | --- | --- | --- | --- | --- | --- |
| 283 | 40 | **Magnet 18 Assembly** |  | 65d | 2022-01-26 | 2022-04-26 |  | 308d |  |
| 284 | 40.1 | Yoke Shell Assembly |  | 20d | 2022-01-26 | 2022-02-22 | 282FS-25d | 313d | 5d |
| 285 | 40.2 | Coil Acceptance |  | 12d | 2022-03-02 | 2022-03-17 | 284, 282 | 308d | 0d |
| 286 | 40.3 | Coil Pack Assembly |  | 20d | 2022-03-18 | 2022-04-14 | 285 | 308d | 0d |
| 287 | 40.4 | Magnet Pre-load |  | 8d | 2022-04-15 | 2022-04-26 | 286 | 308d |  |
| 288 | 41 | **Magnet 19 Coils 41,42** |  | 388d | 2020-10-28 | 2022-04-22 |  | 285d |  |
| 289 | 41.1 | Procure Strand Coil 41 | milestone | 0d | 2020-10-28 | 2020-10-28 | 290SF-250d | 698d |  |
| 290 | 41.2 | Fabricate Cable Coil 41 |  | 35d | 2021-10-13 | 2021-12-01 | 292SF | 413d | 0d |
| 291 | 41.3 | Procure Parts Coil 41 | milestone | 0d | 2021-06-09 | 2021-06-09 | 292SF-125d | 538d |  |
| 292 | 41.4 | Fabricate Coil 41 |  | 84d | 2021-12-01 | 2022-03-28 | 282FF+19d | 0d |  |
| 293 | 41.5 | Procure Strand Coil 42 | milestone | 0d | 2020-11-24 | 2020-11-24 | 294SF-250d | 679d |  |
| 294 | 41.6 | Fabricate Cable Coil 42 |  | 35d | 2021-11-09 | 2021-12-28 | 296SF | 394d | 0d |
| 295 | 41.7 | Procure Parts Coil 42 | milestone | 0d | 2021-07-06 | 2021-07-06 | 296SF-125d | 519d |  |
| 296 | 41.8 | Fabricate Coil 42 |  | 84d | 2021-12-28 | 2022-04-22 | 292FF+19d | 0d |  |
| 297 | 42 | **Magnet 19 Assembly** |  | 65d | 2022-03-21 | 2022-06-17 |  | 270d |  |
| 298 | 42.1 | Yoke Shell Assembly |  | 20d | 2022-03-21 | 2022-04-15 | 296FS-25d | 275d | 5d |
| 299 | 42.2 | Coil Acceptance |  | 12d | 2022-04-25 | 2022-05-10 | 298, 296 | 270d | 0d |
| 300 | 42.3 | Coil Pack Assembly |  | 20d | 2022-05-11 | 2022-06-07 | 299 | 270d | 0d |
| 301 | 42.4 | Magnet Pre-load |  | 8d | 2022-06-08 | 2022-06-17 | 300 | 270d |  |
| 302 | 43 | **Magnet 20 Coils 43,44** |  | 388d | 2020-12-21 | 2022-06-15 |  | 272d |  |
| 303 | 43.1 | Procure Strand Coil 43 | milestone | 0d | 2020-12-21 | 2020-12-21 | 304SF-250d | 660d |  |
| 304 | 43.2 | Fabricate Cable Coil 43 |  | 35d | 2021-12-06 | 2022-01-24 | 306SF | 375d | 0d |
| 305 | 43.3 | Procure Parts Coil 43 | milestone | 0d | 2021-08-02 | 2021-08-02 | 306SF-125d | 500d |  |
| 306 | 43.4 | Fabricate Coil 43 |  | 84d | 2022-01-24 | 2022-05-19 | 296FF+19d | 0d |  |
| 307 | 43.5 | Procure Strand Coil 44 | milestone | 0d | 2021-01-15 | 2021-01-15 | 308SF-250d | 641d |  |
| 308 | 43.6 | Fabricate Cable Coil 44 |  | 35d | 2021-12-31 | 2022-02-18 | 310SF | 356d | 0d |
| 309 | 43.7 | Procure Parts Coil 44 | milestone | 0d | 2021-08-27 | 2021-08-27 | 310SF-125d | 481d |  |
| 310 | 43.8 | Fabricate Coil 44 |  | 84d | 2022-02-18 | 2022-06-15 | 306FF+19d | 0d |  |

| ID | WBS | Task | Type | Duration | Start | Finish | Predecessors | Total slack | Free slack |
| --- | --- | --- | --- | --- | --- | --- | --- | --- | --- |
| 311 | 44 | **Magnet 20 Assembly** |  | 65d | 2022-05-12 | 2022-08-10 |  | 184d |  |
| 312 | 44.1 | Yoke Shell Assembly |  | 20d | 2022-05-12 | 2022-06-08 | 310FS-25d | 189d | 5d |
| 313 | 44.2 | Coil Acceptance |  | 12d | 2022-06-16 | 2022-07-01 | 312, 310 | 184d | 0d |
| 314 | 44.3 | Coil Pack Assembly |  | 20d | 2022-07-04 | 2022-07-29 | 313 | 184d | 0d |
| 315 | 44.4 | Magnet Pre-load |  | 8d | 2022-08-01 | 2022-08-10 | 314 | 184d | 0d |
| 316 | 45 | **Spare Coil 45** |  | 369d | 2021-02-11 | 2022-07-12 |  | 253d |  |
| 317 | 45.1 | Procure Strand Coil 45 | milestone | 0d | 2021-02-11 | 2021-02-11 | 318SF-250d | 622d |  |
| 318 | 45.2 | Fabricate Cable Coil 45 |  | 35d | 2022-01-27 | 2022-03-17 | 320SF | 337d | 0d |
| 319 | 45.3 | Procure Parts Coil 45 | milestone | 0d | 2021-09-23 | 2021-09-23 | 320SF-125d | 462d |  |
| 320 | 45.4 | Fabricate Coil 45 |  | 84d | 2022-03-17 | 2022-07-12 | 310FF+19d | 0d |  |
| 321 | 46 | **Magnet Rework Slot 4** |  | 69d | 2022-07-13 | 2022-10-17 |  | 184d |  |
| 322 | 46.1 | Dis Assemble Coil Pack |  | 20d | 2022-08-11 | 2022-09-07 | 315 | 184d | 0d |
| 323 | 46.2 | Coil Acceptance |  | 12d | 2022-07-13 | 2022-07-28 | 320 | 213d | 29d |
| 324 | 46.3 | Coil Pack Assembly |  | 20d | 2022-09-08 | 2022-10-05 | 323, 322 | 184d | 0d |
| 325 | 46.4 | Magnet Pre-load |  | 8d | 2022-10-06 | 2022-10-17 | 324 | 184d |  |
| 326 | 47 | Coil Pack Assembly |  | 58d | 2022-07-13 | 2022-09-30 | 320 | 0d |  |
| 327 | 48 | Magnet Assembly |  | 34d | 2022-10-03 | 2022-11-17 | 326 | 0d |  |
| 328 | 49 | Vertical Test Prep |  | 13d | 2022-11-18 | 2022-12-06 | 327 | 0d |  |
| 329 | 50 | Vertical Test |  | 24d | 2022-12-07 | 2023-01-09 | 328 | 0d |  |
| 330 | 51 | Ship to FNAL |  | 7d | 2023-01-10 | 2023-01-18 | 329 | 0d |  |
| 331 | 52 | Cold Mass Assembly |  | 42d | 2023-01-19 | 2023-03-17 | 330 | 0d |  |
| 332 | 53 | Horizontal Test Prep |  | 30d | 2023-03-20 | 2023-04-28 | 331 | 0d |  |
| 333 | 54 | Horizontal Test |  | 30d | 2023-05-01 | 2023-06-09 | 332 | 0d |  |
| 334 | 55 | Ship to CERN |  | 15d | 2023-06-12 | 2023-06-30 | 333 | 0d |  |
